# Roadmap_v1.0_

Schedule from MS Project, 2023-08-08 to 2023-08-21.

## Calendars

- Standard: Mon-Fri 08:00-12:00, 13:00-17:00; Sat-Sun off.

## Resources

| Resource |
| --- |
| MB |
| VW |
| BMW |
| TS |

## Schedule

| ID | Task | Type | Duration | Start | Finish | Predecessors | Resources | Work |
| --- | --- | --- | --- | --- | --- | --- | --- | --- |
| 1 | GUI Code and Usability Testing | manual | 3d | 2023-08-08 | 2023-08-10 |  | MB | 24h |
| 2 | Documentation Testing | manual | 3d | 2023-08-08 | 2023-08-10 |  | MB | 24h |
| 3 | VW GUI improvements, CI and MR | manual | 4d | 2023-08-11 | 2023-08-16 | 1, 2 | VW | 32h |
| 4 | Review VW MR | manual | 2d | 2023-08-17 | 2023-08-18 | 3 | MB | 16h |
| 5 | BMW MR synch (SSP, …) | manual | 1d | 2023-08-14 | 2023-08-14 |  | BMW | 8h |
| 6 | BMW MR SCM | manual | 1d | 2023-08-14 | 2023-08-14 |  | BMW | 8h |
| 7 | Review of BMW MRs | manual | 4d | 2023-08-15 | 2023-08-18 | 5, 6 | MB | 32h |
| 8 | Merge Develop into Main, tag v1.0, update docu | manual | 1d | 2023-08-21 | 2023-08-21 | 3, 7 | TS | 8h |
